# 20260316_Zeitplan Nacke Logistik

Schedule from GanttProject, 2025-12-16 to 2026-10-16.

## Calendars

- Project calendar: Mon-Fri working; Sat-Sun off.

## Schedule

| ID | Task | Duration | Start | Finish | Predecessors |
| --- | --- | --- | --- | --- | --- |
| 1 | Bestellung/ Anzahlung | 1d | 2025-12-16 | 2025-12-16 |  |
| 2 | Freigabe Layout | 40d | 2026-01-29 | 2026-03-25 |  |
| 3 | Pflichtenheft erstellen | 33d | 2026-03-26 | 2026-05-11 | 2 |
| 4 | Bestellung Fahrstrecken | 6d | 2026-03-26 | 2026-04-02 | 2 |
| 5 | Bestellung Gerüst | 6d | 2026-03-26 | 2026-04-02 | 2 |
| 6 | Beschaffung Produktion | 66d | 2026-04-03 | 2026-07-03 | 4, 5 |
| 7 | Transport/ Anlieferung | 1d | 2026-07-06 | 2026-07-06 | 6 |
| 8 | Montage Gerüst_Fördertechnik | 69d | 2026-07-07 | 2026-10-09 | 7 |
| 9 | Montage elektrisch | 8d | 2026-09-24 | 2026-10-05 |  |
| 10 | Inbetriebnahme | 5d | 2026-10-06 | 2026-10-12 | 9 |
| 11 | Puffer Restarbeiten | 3d | 2026-10-13 | 2026-10-15 | 8, 10 |
| 12 | Abnahme | 1d | 2026-10-16 | 2026-10-16 | 11 |
